# Office Remodel

Schedule from MS Project, 2021-10-12 to 2021-11-23.
Workspace
Paper Division
Goal: Modernize the look of the office

## Calendars

- Standard: Mon-Fri 08:00-12:00, 13:00-17:00; Sat-Sun off. Exceptions (off unless hours are given): 2021-10-29 08:00-12:00 (Fall Harvest Festival), 2021-11-11 (Remembrance Day (stat)).

## Schedule

| ID | WBS | Task | Type | Duration | Start | Finish | Predecessors | Total slack | Free slack |
| --- | --- | --- | --- | --- | --- | --- | --- | --- | --- |
| 1 | 1 | **Space planning** |  | 12d | 2021-10-12 | 2021-10-27 |  | 0d |  |
| 2 | 1.1 | Interview space planners |  | 5d | 2021-10-12 | 2021-10-18 |  | 0d |  |
| 3 | 1.2 | Hire space planner |  | 2d | 2021-10-19 | 2021-10-20 | 2 | 0d |  |
| 4 | 1.3 | Meet with space planner |  | 2d | 2021-10-21 | 2021-10-22 | 3 | 0d |  |
| 5 | 1.4 | Finalize space plan |  | 3d | 2021-10-25 | 2021-10-27 | 4 | 0d |  |
| 6 | 1.5 | Space planning complete | milestone | 0d | 2021-10-27 | 2021-10-27 | 5 | 0d |  |
| 7 | 2 | **Furniture Selection** |  | 11.5d | 2021-10-28 | 2021-11-15 |  | 0d |  |
| 8 | 2.1 | Preview furniture selection |  | 2d | 2021-10-28 | 2021-11-01 | 6 | 0d |  |
| 9 | 2.2 | Select new furniture |  | 1d | 2021-11-01 | 2021-11-02 | 8 | 0d |  |
| 10 | 2.3 | Order new furniture |  | 0.5d | 2021-11-02 | 2021-11-02 | 9 | 0d |  |
| 11 | 2.4 | Delivery time |  | 8d | 2021-11-03 | 2021-11-15 | 10 | 0d |  |
| 12 | 2.5 | Furniture delivered | milestone | 0d | 2021-11-15 | 2021-11-15 | 11 | 0d |  |
| 13 | 3 | **Office remodel** |  | 9d | 2021-10-28 | 2021-11-10 |  | 3d |  |
| 14 | 3.1 | Hire contractor |  | 4d | 2021-10-28 | 2021-11-03 | 6 | 3d | 0d |
| 15 | 3.2 | Remodel workspace |  | 5d | 2021-11-03 | 2021-11-10 | 14 | 8.5d | 0d |
| 16 | 3.3 | Remodel complete | milestone | 0d | 2021-11-10 | 2021-11-10 | 15 | 8.5d |  |
| 17 | 4 | **Move to new office** |  | 13.5d? | 2021-11-03 | 2021-11-23 |  | 0d |  |
| 18 | 4.1 | Hire mover |  | 2d | 2021-11-03 | 2021-11-05 | 14 | 3d | 0d |
| 19 | 4.2 | Pack workspace |  | 1d | 2021-11-05 | 2021-11-08 | 18 | 3d | 0d |
| 20 | 4.3 | Move equipment |  | 0.5d | 2021-11-08 | 2021-11-08 | 19 | 3d | 0d |
| 21 | 4.4 | Remove existing furniture |  | 1d? | 2021-11-09 | 2021-11-09 | 20 | 3d |  |
| 22 | 4.5 | Assemble new furniture |  | 2d | 2021-11-16 | 2021-11-17 | 21, 12 | 0d |  |
| 23 | 4.6 | Return equipment |  | 1d? | 2021-11-18 | 2021-11-18 | 22 | 0d |  |
| 24 | 4.7 | Unpack workspace |  | 2d | 2021-11-19 | 2021-11-22 | 23 | 0d |  |
| 25 | 4.8 | Workspace final clean |  | 1d? | 2021-11-23 | 2021-11-23 | 24 | 0d |  |
| 26 | 5 | Office remodel complete | milestone | 0d | 2021-11-23 | 2021-11-23 | 25 | 0d |  |
