# Office Remodel

Schedule from MS Project, 2021-10-12 to 2021-11-19.
Workspace
Paper Division
Goal: Modernize the look of the office

## Calendars

- Standard: Mon-Fri 08:00-12:00, 13:00-17:00; Sat-Sun off. Exceptions (off unless hours are given): 2021-10-29 08:00-12:00 (Fall Harvest Festival), 2021-11-11 (Remembrance Day (stat)).

## Schedule

| ID | WBS | Task | Type | Duration | Start | Finish | Predecessors | Total slack | Free slack |
| --- | --- | --- | --- | --- | --- | --- | --- | --- | --- |
| 1 | 1 | **Space planning** |  | 12d | 2021-10-12 | 2021-10-27 |  | 0d |  |
| 2 | 1.1 | Interview space planners |  | 5d | 2021-10-12 | 2021-10-18 |  | 0d |  |
| 3 | 1.2 | Hire space planner |  | 2d | 2021-10-19 | 2021-10-20 | 2 | 0d |  |
| 4 | 1.3 | Meet with space planner |  | 2d | 2021-10-21 | 2021-10-22 | 3 | 0d |  |
| 5 | 1.4 | Finalize space plan |  | 3d | 2021-10-25 | 2021-10-27 | 4 | 0d |  |
| 6 | 1.5 | Space planning complete | milestone | 0d | 2021-10-27 | 2021-10-27 | 5 | 0d |  |
| 7 | 2 | **Furniture Selection** |  | 11.5d | 2021-10-28 | 2021-11-15 |  | 2d |  |
| 8 | 2.1 | Preview furniture selection |  | 2d | 2021-10-28 | 2021-11-01 | 6 | 2d | 0d |
| 9 | 2.2 | Select new furniture |  | 1d | 2021-11-01 | 2021-11-02 | 8 | 2d | 0d |
| 10 | 2.3 | Order new furniture |  | 0.5d | 2021-11-02 | 2021-11-02 | 9 | 2d | 0d |
| 11 | 2.4 | Delivery time |  | 8d | 2021-11-03 | 2021-11-15 | 10 | 2d | 0d |
| 12 | 2.5 | Furniture delivered | milestone | 0d | 2021-11-15 | 2021-11-15 | 11 | 2d | 1.5d |
| 13 | 3 | **Office remodel** |  | 12d | 2021-10-28 | 2021-11-16 |  | 0d |  |
| 14 | 3.1 | Hire contractor |  | 4d | 2021-10-28 | 2021-11-03 | 6 | 0d |  |
| 15 | 3.2 | Remodel workspace |  | 5d | 2021-11-08 | 2021-11-16 | 14FS+3d | 0d |  |
| 16 | 3.3 | Remodel complete | milestone | 0d | 2021-11-16 | 2021-11-16 | 15 | 0d |  |
| 17 | 4 | **Move to new office** |  | 11.5d | 2021-11-03 | 2021-11-19 |  | 0d |  |
| 18 | 4.1 | Hire mover |  | 2d | 2021-11-03 | 2021-11-05 | 14 | 5d |  |
| 19 | 4.2 | Pack workspace |  | 1d | 2021-11-15 | 2021-11-16 | 18, 16FS-1d | 0d |  |
| 20 | 4.3 | Move equipment |  | 0.5d | 2021-11-16 | 2021-11-16 | 19 | 0d |  |
| 21 | 4.4 | Remove existing furniture |  | 1d | 2021-11-16 | 2021-11-17 | 20SS | 0.5d | 0d |
| 22 | 4.5 | Assemble new furniture |  | 2d | 2021-11-17 | 2021-11-19 | 21, 12 | 0.5d |  |
| 23 | 4.6 | Return equipment |  | 1d | 2021-11-17 | 2021-11-17 | 20 | 2d |  |
| 24 | 4.7 | Unpack workspace |  | 2d | 2021-11-17 | 2021-11-18 | 20 | 0d |  |
| 25 | 4.8 | Workspace final clean |  | 1d | 2021-11-19 | 2021-11-19 | 24 | 0d |  |
| 26 | 5 | Office remodel complete | milestone | 0d | 2021-11-19 | 2021-11-19 | 25 | 0d |  |
