# Office Remodel

Schedule from MS Project, 2021-10-12 to 2021-11-25.
Workspace
Paper Division
Goal: Modernize the look of the office

## Calendars

- Standard: Mon-Fri 08:00-12:00, 13:00-17:00; Sat-Sun off. Exceptions (off unless hours are given): 2021-10-29 08:00-12:00 (Fall Harvest Festival), 2021-11-11 (Remembrance Day (stat)).

## Resources

| Resource | Group |
| --- | --- |
| President | Management |
| Office Manager | Management |
| Administrative Assistant | Office Staff |
| Operations Manager | Management |
| Space Planner | Contract |
| Janitor | Maintenance |
| Contractor | Contract |
| Mover | Outside Service |

## Schedule

| ID | WBS | Task | Type | Duration | Start | Finish | Predecessors | Total slack | Free slack | Constraint | Deadline | Resources | Work |
| --- | --- | --- | --- | --- | --- | --- | --- | --- | --- | --- | --- | --- | --- |
| 1 | 1 | **Space planning** |  | 13d | 2021-10-12 | 2021-10-28 |  | 0d |  |  |  |  | 256h |
| 2 | 1.1 | Interview space planners |  | 5d | 2021-10-12 | 2021-10-18 |  | 1d | 0d |  |  | Office Manager; Operations Manager; President | 120h |
| 3 | 1.2 | Hire space planner |  | 2d | 2021-10-19 | 2021-10-20 | 2 | 1d | 0d |  |  | President; Administrative Assistant | 32h |
| 4 | 1.3 | Meet with space planner |  | 2d | 2021-10-21 | 2021-10-22 | 3 | 1d | 0d |  |  | Office Manager; Operations Manager; Space Planner; President; Administrative Assistant | 80h |
| 5 | 1.4 | Finalize space plan |  | 3d | 2021-10-25 | 2021-10-27 | 4 | 1d |  |  |  | Space Planner | 24h |
| 6 | 1.5 | Space planning complete | milestone | 0d | 2021-10-28 | 2021-10-28 | 5 | 0d |  | finish no earlier than 2021-10-28 | 2021-10-28 |  |  |
| 7 | 2 | **Furniture Selection** |  | 11d | 2021-10-29 | 2021-11-16 |  | 4.5d |  |  |  |  | 74h |
| 8 | 2.1 | Preview furniture selection |  | 2d | 2021-10-29 | 2021-11-02 | 6 | 4.5d | 0d |  |  | Administrative Assistant; Office Manager; Operations Manager | 48h |
| 9 | 2.2 | Select new furniture |  | 1d | 2021-11-02 | 2021-11-03 | 8 | 4.5d | 0d |  |  | Operations Manager; Office Manager | 16h |
| 10 | 2.3 | Order new furniture |  | 0.5d | 2021-11-03 | 2021-11-03 | 9 | 4.5d | 0d |  |  | Administrative Assistant | 4h |
| 11 | 2.4 | Delivery time |  | 7.5d | 2021-11-04 | 2021-11-16 | 10 | 4.5d | 0d |  |  | Administrative Assistant [10%] | 6h |
| 12 | 2.5 | Furniture delivered | milestone | 0d | 2021-11-16 | 2021-11-16 | 11 | 4.5d | 3.5d |  | 2021-11-22 |  |  |
| 13 | 3 | **Office remodel** |  | 13.5d | 2021-10-29 | 2021-11-18 |  | 0d |  |  |  |  | 104h |
| 14 | 3.1 | Hire contractor |  | 4d | 2021-10-29 | 2021-11-04 | 6 | 1.5d | 0d |  |  | President; Operations Manager | 64h |
| 15 | 3.2 | Remodel workspace |  | 5d | 2021-11-09 | 2021-11-17 | 14FS+3d | 1.5d |  |  |  | Contractor | 40h |
| 16 | 3.3 | Remodel complete | milestone | 0d | 2021-11-18 | 2021-11-18 | 15 | 0d |  | finish no earlier than 2021-11-18 | 2021-11-18 |  |  |
| 17 | 4 | **Move to new office** |  | 14.5d | 2021-11-04 | 2021-11-25 |  | 0d |  |  |  |  | 152h |
| 18 | 4.1 | Hire mover |  | 2d | 2021-11-04 | 2021-11-08 | 14 | 8d | 6.5d |  |  | Operations Manager; Office Manager | 32h |
| 19 | 4.2 | Pack workspace |  | 1d | 2021-11-18 | 2021-11-18 | 18, 16FS-1d | 1.5d | 0d |  |  | Office Manager; Mover | 16h |
| 20 | 4.3 | Move equipment |  | 0.5d | 2021-11-19 | 2021-11-19 | 19 | 1.5d | 0d |  |  | Office Manager; Mover | 8h |
| 21 | 4.4 | Remove existing furniture |  | 1d | 2021-11-19 | 2021-11-19 | 20SS | 2d | 0d |  |  | Mover | 8h |
| 22 | 4.5 | Assemble new furniture |  | 2d | 2021-11-22 | 2021-11-23 | 21, 12 | 2d |  |  |  | Space Planner; Mover | 32h |
| 23 | 4.6 | Return equipment |  | 1d | 2021-11-19 | 2021-11-22 | 20 | 3.5d |  |  |  | Office Manager; Mover | 16h |
| 24 | 4.7 | Unpack workspace |  | 2d | 2021-11-19 | 2021-11-23 | 20 | 1.5d | 0d |  |  | Administrative Assistant; Mover | 32h |
| 25 | 4.8 | Workspace final clean |  | 1d | 2021-11-23 | 2021-11-24 | 24 | 1.5d |  |  |  | Janitor | 8h |
| 26 | 4.9 | New office move complete | milestone | 0d | 2021-11-25 | 2021-11-25 | 25, 22, 23 | 0d |  | finish no earlier than 2021-11-25 |  |  |  |
| 27 | 5 | Office remodel complete | milestone | 0d | 2021-11-25 | 2021-11-25 | 25, 26 | 0d |  |  | 2021-11-25 |  |  |
