# Office Remodel

Schedule from MS Project, 2021-10-12 to 2021-11-25.
Workspace
Paper Division
Goal: Modernize the look of the office

## Calendars

- Standard: Mon-Fri 08:00-12:00, 13:00-17:00; Sat-Sun off. Exceptions (off unless hours are given): 2021-10-29 08:00-12:00 (Fall Harvest Festival), 2021-11-11 (Remembrance Day (stat)).

## Schedule

| ID | WBS | Task | Type | Duration | Start | Finish | Predecessors | Total slack | Free slack | Constraint | Deadline |
| --- | --- | --- | --- | --- | --- | --- | --- | --- | --- | --- | --- |
| 1 | 1 | **Space planning** |  | 13d | 2021-10-12 | 2021-10-28 |  | 0d |  |  |  |
| 2 | 1.1 | Interview space planners |  | 5d | 2021-10-12 | 2021-10-18 |  | 1d | 0d |  |  |
| 3 | 1.2 | Hire space planner |  | 2d | 2021-10-19 | 2021-10-20 | 2 | 1d | 0d |  |  |
| 4 | 1.3 | Meet with space planner |  | 2d | 2021-10-21 | 2021-10-22 | 3 | 1d | 0d |  |  |
| 5 | 1.4 | Finalize space plan |  | 3d | 2021-10-25 | 2021-10-27 | 4 | 1d |  |  |  |
| 6 | 1.5 | Space planning complete | milestone | 0d | 2021-10-28 | 2021-10-28 | 5 | 0d |  | finish no earlier than 2021-10-28 | 2021-10-28 |
| 7 | 2 | **Furniture Selection** |  | 11.5d | 2021-10-29 | 2021-11-16 |  | 4d |  |  |  |
| 8 | 2.1 | Preview furniture selection |  | 2d | 2021-10-29 | 2021-11-02 | 6 | 4d | 0d |  |  |
| 9 | 2.2 | Select new furniture |  | 1d | 2021-11-02 | 2021-11-03 | 8 | 4d | 0d |  |  |
| 10 | 2.3 | Order new furniture |  | 0.5d | 2021-11-03 | 2021-11-03 | 9 | 4d | 0d |  |  |
| 11 | 2.4 | Delivery time |  | 8d | 2021-11-04 | 2021-11-16 | 10 | 4d | 0d |  |  |
| 12 | 2.5 | Furniture delivered | milestone | 0d | 2021-11-16 | 2021-11-16 | 11 | 4d | 3d |  | 2021-11-22 |
| 13 | 3 | **Office remodel** |  | 13.5d | 2021-10-29 | 2021-11-18 |  | 0d |  |  |  |
| 14 | 3.1 | Hire contractor |  | 4d | 2021-10-29 | 2021-11-04 | 6 | 1.5d | 0d |  |  |
| 15 | 3.2 | Remodel workspace |  | 5d | 2021-11-09 | 2021-11-17 | 14FS+3d | 1.5d |  |  |  |
| 16 | 3.3 | Remodel complete | milestone | 0d | 2021-11-18 | 2021-11-18 | 15 | 0d |  | finish no earlier than 2021-11-18 | 2021-11-18 |
| 17 | 4 | **Move to new office** |  | 14.5d | 2021-11-04 | 2021-11-25 |  | 0d |  |  |  |
| 18 | 4.1 | Hire mover |  | 2d | 2021-11-04 | 2021-11-08 | 14 | 8d | 6.5d |  |  |
| 19 | 4.2 | Pack workspace |  | 1d | 2021-11-18 | 2021-11-18 | 18, 16FS-1d | 1.5d | 0d |  |  |
| 20 | 4.3 | Move equipment |  | 0.5d | 2021-11-19 | 2021-11-19 | 19 | 1.5d | 0d |  |  |
| 21 | 4.4 | Remove existing furniture |  | 1d | 2021-11-19 | 2021-11-19 | 20SS | 2d | 0d |  |  |
| 22 | 4.5 | Assemble new furniture |  | 2d | 2021-11-22 | 2021-11-23 | 21, 12 | 2d |  |  |  |
| 23 | 4.6 | Return equipment |  | 1d | 2021-11-19 | 2021-11-22 | 20 | 3.5d |  |  |  |
| 24 | 4.7 | Unpack workspace |  | 2d | 2021-11-19 | 2021-11-23 | 20 | 1.5d | 0d |  |  |
| 25 | 4.8 | Workspace final clean |  | 1d | 2021-11-23 | 2021-11-24 | 24 | 1.5d |  |  |  |
| 26 | 4.9 | New office move complete | milestone | 0d | 2021-11-25 | 2021-11-25 | 25, 22, 23 | 0d |  | finish no earlier than 2021-11-25 |  |
| 27 | 5 | Office remodel complete | milestone | 0d | 2021-11-25 | 2021-11-25 | 25, 26 | 0d |  |  | 2021-11-25 |
