# Office Remodel

Schedule from MS Project, 2021-10-12 to 2021-11-25, costs in $.
Workspace
Paper Division
Goal: Modernize the look of the office

## Calendars

- Standard: Mon-Fri 08:00-12:00, 13:00-17:00; Sat-Sun off. Exceptions (off unless hours are given): 2021-10-29 08:00-12:00 (Fall Harvest Festival), 2021-11-11 (Remembrance Day (stat)).
- Freight Elevator: Mon-Fri 16:00-20:00; Sat-Sun off. Exceptions (off unless hours are given): 2021-10-29 08:00-12:00 (Fall Harvest Festival), 2021-11-11 (Remembrance Day (stat)).

## Resources

| Resource | Group | Rate | Notes |
| --- | --- | --- | --- |
| President | Management |  |  |
| Office Manager | Management | 24.04 |  |
| Administrative Assistant | Office Staff | 20 |  |
| Operations Manager | Management | 28.85 |  |
| Space Planner | Contract |  |  |
| Janitor | Maintenance | 16 | The cost rate table B is for construction cleaning tasks. |
| Contractor | Contract |  |  |
| Mover | Outside Service |  |  |

## Schedule

| ID | WBS | Task | Type | Duration | Start | Finish | Predecessors | Baseline start | Baseline finish | Baseline duration | Total slack | Free slack | Constraint | Deadline | Calendar | Resources | Work | Cost | Baseline cost |
| --- | --- | --- | --- | --- | --- | --- | --- | --- | --- | --- | --- | --- | --- | --- | --- | --- | --- | --- | --- |
| 1 | 1 | **Space planning** |  | 13d | 2021-10-12 | 2021-10-28 |  | 2021-10-12 | 2021-10-28 | 13d | 0d |  |  |  |  |  | 158h | 1,904.42 | 1,904.42 |
| 2 | 1.1 | Interview space planners |  | 5d | 2021-10-12 | 2021-10-18 |  | 2021-10-12 | 2021-10-18 | 5d | 1.75d | 0d |  |  |  | Office Manager; Operations Manager; President | 22h | 418.27 | 418.27 |
| 3 | 1.2 | Hire space planner |  | 2d | 2021-10-19 | 2021-10-20 | 2 | 2021-10-19 | 2021-10-20 | 2d | 1.75d | 0d |  |  |  | President; Administrative Assistant | 32h | 320 | 320 |
| 4 | 1.3 | Meet with space planner |  | 2d | 2021-10-21 | 2021-10-22 | 3 | 2021-10-21 | 2021-10-22 | 2d | 1.75d | 0d |  |  |  | Office Manager; Operations Manager; Space Planner; President; Administrative Assistant | 80h | 1,166.15 | 1,166.15 |
| 5 | 1.4 | Finalize space plan |  | 2.25d | 2021-10-25 | 2021-10-27 | 4 | 2021-10-25 | 2021-10-27 | 2.25d | 1.75d |  |  |  |  | Space Planner | 24h |  |  |
| 6 | 1.5 | Space planning complete | milestone | 0d | 2021-10-28 | 2021-10-28 | 5 | 2021-10-28 | 2021-10-28 | 0d | 0d |  | finish no earlier than 2021-10-28 | 2021-10-28 |  |  |  |  |  |
| 7 | 2 | **Furniture Selection** |  | 12.5d | 2021-10-29 | 2021-11-17 |  | 2021-10-29 | 2021-11-17 | 12.5d | 3d |  |  |  |  |  | 42.8h | 632.54 | 632.54 |
| 8 | 2.1 | Preview furniture selection |  | 3d | 2021-10-29 | 2021-11-03 | 6 | 2021-10-29 | 2021-11-03 | 3d | 3.5d | 0d |  |  |  | Administrative Assistant [20%]; Office Manager [25%]; Space Planner [25%] | 16.8h | 240.23 | 240.23 |
| 9 | 2.2 | Select new furniture |  | 1d | 2021-11-03 | 2021-11-04 | 8 | 2021-11-03 | 2021-11-04 | 1d | 3.5d | 0d |  |  |  | Office Manager; Space Planner | 16h | 192.31 | 192.31 |
| 10 | 2.3 | Order new furniture |  | 0.5d | 2021-11-04 | 2021-11-04 | 9 | 2021-11-04 | 2021-11-04 | 0.5d | 3.5d | 0.5d |  |  |  | Administrative Assistant | 4h | 80 | 80 |
| 11 | 2.4 | Delivery time |  | 7.5d | 2021-11-05 | 2021-11-17 | 10 | 2021-11-05 | 2021-11-17 | 7.5d | 3d | 0d | finish no earlier than 2021-11-17 |  |  | Administrative Assistant [10%] | 6h | 120 | 120 |
| 12 | 2.5 | Furniture delivered | milestone | 0d | 2021-11-17 | 2021-11-17 | 11 | 2021-11-17 | 2021-11-17 | 0d | 3d |  |  | 2021-11-22 |  |  |  |  |  |
| 13 | 3 | **Office remodel** |  | 13.5d | 2021-10-29 | 2021-11-18 |  | 2021-10-29 | 2021-11-18 | 13.5d | 0d |  |  |  |  |  | 144h | 13,423.08 | 13,423.08 |
| 14 | 3.1 | Hire contractor |  | 4d | 2021-10-29 | 2021-11-04 | 6 | 2021-10-29 | 2021-11-04 | 4d | 1.5d | 0d |  |  |  | President; Operations Manager | 64h | 923.08 | 923.08 |
| 15 | 3.2 | Remodel workspace |  | 5d | 2021-11-09 | 2021-11-17 | 14FS+3d | 2021-11-09 | 2021-11-17 | 5d | 1.5d |  |  |  |  | Contractor [200%] | 80h | 12,500 | 12,500 |
| 16 | 3.3 | Remodel complete | milestone | 0d | 2021-11-18 | 2021-11-18 | 15 | 2021-11-18 | 2021-11-18 | 0d | 0d |  | finish no earlier than 2021-11-18 | 2021-11-18 |  |  |  |  |  |
| 17 | 4 | **Move to new office** |  | 14.5d | 2021-11-04 | 2021-11-25 |  | 2021-11-04 | 2021-11-25 | 14.5d | 0d |  |  |  |  |  | 112h | 1,838.92 | 1,838.92 |
| 18 | 4.1 | Hire mover |  | 2.5d | 2021-11-04 | 2021-11-15 | 14 | 2021-11-04 | 2021-11-15 | 2.5d | 4d | 2.5d |  |  |  | Operations Manager; Office Manager | 32h | 846.15 | 846.15 |
| 19 | 4.2 | Pack workspace |  | 1d | 2021-11-18 | 2021-11-18 | 18, 16FS-1d | 2021-11-18 | 2021-11-18 | 1d | 1.5d | 0d |  |  |  | Office Manager; Mover | 16h | 192.31 | 192.31 |
| 20 | 4.3 | Move equipment |  | 0.5d | 2021-11-19 | 2021-11-19 | 19 | 2021-11-19 | 2021-11-19 | 0.5d | 1.5d | 0d |  |  |  | Office Manager; Mover | 8h | 96.15 | 96.15 |
| 21 | 4.4 | Remove existing furniture |  | 1d | 2021-11-19 | 2021-11-23 | 20SS | 2021-11-19 | 2021-11-23 | 1d | 0.12d | 0d |  |  | Freight Elevator | Mover | 8h |  |  |
| 22 | 4.5 | Assemble new furniture |  | 2d | 2021-11-23 | 2021-11-25 | 21, 12 | 2021-11-23 | 2021-11-25 | 2d | 0d |  |  |  |  | Space Planner; Mover | 16h |  |  |
| 23 | 4.6 | Return equipment |  | 1d | 2021-11-19 | 2021-11-22 | 20 | 2021-11-19 | 2021-11-22 | 1d | 3.5d |  |  |  |  | Office Manager; Mover | 8h | 192.31 | 192.31 |
| 24 | 4.7 | Unpack workspace |  | 2d | 2021-11-19 | 2021-11-23 | 20 | 2021-11-19 | 2021-11-23 | 2d | 1.5d | 0d |  |  |  | Administrative Assistant | 16h | 320 | 320 |
| 25 | 4.8 | Workspace final clean |  | 1d | 2021-11-23 | 2021-11-25 | 24 | 2021-11-23 | 2021-11-25 | 1d | 0.5d |  |  |  |  | Janitor | 8h | 192 | 192 |
| 26 | 4.9 | New office move complete | milestone | 0d | 2021-11-25 | 2021-11-25 | 25, 22, 23 | 2021-11-25 | 2021-11-25 | 0d | 0d |  | finish no earlier than 2021-11-25 |  |  |  |  |  |  |
| 27 | 5 | Office remodel complete | milestone | 0d | 2021-11-25 | 2021-11-25 | 25, 26 | 2021-11-25 | 2021-11-25 | 0d | 0d |  | must finish on 2021-11-25 | 2021-11-25 |  |  |  |  |  |
